# План выполнения работ, ред. 01

Schedule from MS Project, 2017-05-17 to 2017-08-02, costs in р..
***

## Calendars

- Стандартный: Mon-Fri 09:00-13:00, 14:00-18:00; Sat-Sun off.

## Resources

| Resource | Rate |
| --- | --- |
| Руководитель проекта | 1000 |
| Разработчик системы ORACLE 1 | 500 |
| Разработчик системы WEB | 500 |
| Разработчик системы WINDOWS | 500 |
| Сотрудник исполнителя |  |
| Технический специалист | 300 |
| Специалист по внедрению | 400 |
| Разработчик документации | 250 |
| Архитектор системы, |  |
| Разработчик системы Отчетов | 500 |
| Разработчик системы ORACLE 2 | 500 |

## Schedule

| ID | WBS | Task | Duration | Start | Finish | Predecessors | Total slack | Free slack | Constraint | Resources | Work | Cost |
| --- | --- | --- | --- | --- | --- | --- | --- | --- | --- | --- | --- | --- |
| 1 | 1 | **Разработка автоматизированной информационной системы «LM GROUP»** | 56d | 2017-05-17 | 2017-08-02 |  |  |  |  |  | 904h | 440,000 |
| 2 | 1.1 | **Этап 1. Автоматизация БП** | 41d | 2017-05-17 | 2017-07-12 |  |  |  |  | Разработчик системы ORACLE 1 | 784h | 392,000 |
| 3 | 1.1.1 | **Подготовка данных** | 7.5d | 2017-05-17 | 2017-05-26 |  | 0d |  |  | Разработчик системы ORACLE 2 | 60h | 30,000 |
| 4 | 1.1.1.1 | Первичный импорт данных для разработки и тестирования из существующей базы | 3d | 2017-05-17 | 2017-05-19 |  | 0d |  | start no earlier than 2017-05-17 |  |  |  |
| 5 | 1.1.1.2 | Формирование номенклатуры услуг и прайс-листов | 2d | 2017-05-22 | 2017-05-23 | 4 | 0d |  | start no earlier than 2017-05-15 |  |  |  |
| 6 | 1.1.1.3 | Создание маршрутов обработок работ по типам | 1d | 2017-05-24 | 2017-05-24 | 5 | 0d |  |  |  |  |  |
| 7 | 1.1.1.4 | Создание организационной структуры компании и списка ролей | 0.5d | 2017-05-25 | 2017-05-25 | 6 | 0d |  |  |  |  |  |
| 8 | 1.1.1.5 | Формирование базы исполнителей и первичный импорт из существующей базы | 1d | 2017-05-25 | 2017-05-26 | 7 | 0d |  |  |  |  |  |
| 9 | 1.1.2 | **БП Прием заявки на перевод** | 16.5d | 2017-05-26 | 2017-06-19 |  | 0d |  |  | Разработчик системы ORACLE 1 | 132h | 66,000 |
| 10 | 1.1.2.1 | Настройка и разработка функциональности карточки клиента | 5d | 2017-05-26 | 2017-06-02 | 8 | 0d |  |  |  |  |  |
| 11 | 1.1.2.2 | Настройка и разработка функциональности создания заявки | 3d | 2017-06-02 | 2017-06-07 | 10 | 0d |  |  |  |  |  |
| 12 | 1.1.2.3 | Формирование договора от заявки | 1d | 2017-06-07 | 2017-06-08 | 11 | 0d |  | start no earlier than 2017-01-30 |  |  |  |
| 13 | 1.1.2.4 | Формирование маршрута обработки заявки | 0.5d | 2017-06-08 | 2017-06-08 | 12 | 0d |  |  |  |  |  |
| 14 | 1.1.2.5 | Разработка функциональности по расчету стоимости заявки с учетом скидок и наценок | 1d | 2017-06-09 | 2017-06-09 | 13 | 17d | 0d |  |  |  |  |
| 15 | 1.1.2.6 | Настройка и разработка функциональнсоти для подключения к файловому хранилищу | 5d | 2017-06-12 | 2017-06-16 | 14 | 17d | 0d |  |  |  |  |
| 16 | 1.1.2.7 | Разработка отчета КП, Заказ, Счет | 1d | 2017-06-19 | 2017-06-19 | 15 | 17d |  |  |  |  |  |
| 17 | 1.1.3 | **БП Обработка заказа** | 24d | 2017-06-09 | 2017-07-12 |  | 0d |  |  | Разработчик системы ORACLE 1 | 192h | 96,000 |
| 18 | 1.1.3.1 | Настройка функциональности по выбору исполнителей | 2d | 2017-06-09 | 2017-06-12 | 13 | 0d |  |  |  |  |  |
| 19 | 1.1.3.2 | Разработка верстки плагина выбор исполнителя и согласование с заказчиком | 2d | 2017-06-13 | 2017-06-14 | 18 | 0d |  |  |  |  |  |
| 20 | 1.1.3.3 | Разработка плагина выбор и назначение исполнителя | 5d | 2017-06-15 | 2017-06-21 | 19 | 0d |  |  |  |  |  |
| 21 | 1.1.3.4 | Формирования нарядов по выбранным исполнятелям | 1d | 2017-06-22 | 2017-06-22 | 20 | 0d |  |  |  |  |  |
| 22 | 1.1.3.5 | Настройка уведомлений и писем исполнителям. Настрока личного кабинета исполнителя | 2d | 2017-06-23 | 2017-06-26 | 21 | 0d |  |  |  |  |  |
| 23 | 1.1.3.6 | Настройка и разработка передача работ по маршруту обработки | 3d | 2017-06-27 | 2017-06-29 | 22 | 0d |  |  |  |  |  |
| 24 | 1.1.3.7 | Формирование окончательного счета Заказчику и акты выполненных работ | 1d | 2017-06-30 | 2017-06-30 | 23 | 0d |  |  |  |  |  |
| 25 | 1.1.3.8 | Настрока профиля Заказчик и предоставление доступа к системе | 1d | 2017-07-03 | 2017-07-03 | 24 | 0d |  |  |  |  |  |
| 26 | 1.1.3.9 | Предоставление доступа Заказчику к готовым работам (доступ к файлам через выполненные работы) | 3d | 2017-07-04 | 2017-07-06 | 25 | 0d |  |  |  |  |  |
| 27 | 1.1.3.10 | Функциональность возврат работы от Заказчика с оповещением и формированием Претензии | 2d | 2017-07-07 | 2017-07-10 | 26 | 0d |  |  |  |  |  |
| 28 | 1.1.3.11 | Настройка загрузки выписок из банка | 1d | 2017-07-11 | 2017-07-11 | 27 | 0d |  |  |  |  |  |
| 29 | 1.1.3.12 | Настройка распределения платежей по счетам Заказчику и закрытие заявок | 1d | 2017-07-12 | 2017-07-12 | 28 | 0d |  |  |  |  |  |

| ID | WBS | Task | Duration | Start | Finish | Predecessors | Total slack | Resources | Work | Cost |
| --- | --- | --- | --- | --- | --- | --- | --- | --- | --- | --- |
| 30 | 1.1.4 | **БП Оплата услуг внешним исполнителям** | 5d | 2017-06-30 | 2017-07-06 |  | 0d | Разработчик системы ORACLE 1 | 40h | 20,000 |
| 31 | 1.1.4.1 | Отчет «Форма краткого отчета по исполнителям» | 1d | 2017-06-30 | 2017-06-30 | 23 | 0d |  |  |  |
| 32 | 1.1.4.2 | Отчет «Форма подробного отчета по исполнителям» | 2d | 2017-07-03 | 2017-07-04 | 31 | 0d |  |  |  |
| 33 | 1.1.4.3 | Формирование списка выплат переводчикам и отметка о выплате бухгалтером | 2d | 2017-07-05 | 2017-07-06 | 32 | 0d |  |  |  |
| 34 | 1.1.5 | **Разработка отчетных форм** | 4d | 2017-07-07 | 2017-07-12 |  | 0d | Разработчик системы Отчетов | 32h | 16,000 |
| 35 | 1.1.5.1 | Отчет «Претензии» | 1d | 2017-07-07 | 2017-07-07 | 33 | 0d |  |  |  |
| 36 | 1.1.5.2 | Отчет «План поступления» и «Задолженность» | 1d | 2017-07-10 | 2017-07-10 | 35 | 0d |  |  |  |
| 37 | 1.1.5.3 | Отчет «Сумма заказов по контрагенту» | 2d | 2017-07-11 | 2017-07-12 | 36 | 0d |  |  |  |
| 38 | 1.2 | **Этап 4. Тестирование и опытная эксплуатация** | 15d | 2017-07-13 | 2017-08-02 |  | 0d | Специалист по внедрению | 120h | 48,000 |
| 39 | 1.2.1 | Настройка основных пользователей системы | 1d | 2017-07-13 | 2017-07-13 | 37 | 0d |  |  |  |
| 40 | 1.2.2 | Проведение презентации по процессам и исправление замечаний | 7d | 2017-07-14 | 2017-07-24 | 39 | 0d |  |  |  |
| 41 | 1.2.3 | Тестовая эскплуатация АИС ключевыми пользователями и исправление замечаний через инциденты | 7d | 2017-07-25 | 2017-08-02 | 40 | 0d |  |  |  |
